# עסק חדש

Schedule from MS Project, 2018-05-21 to 2018-11-21.

## Calendars

- סטנדרטי: Mon-Thu 08:00-12:00, 13:00-17:00; Fri-Sat off; Sun 08:00-12:00, 13:00-17:00. Exceptions (off unless hours are given): 2018-09-09 to 2018-09-11, 2018-09-18 to 2018-09-19, 2018-09-23 to 2018-09-24, 2018-09-30 to 2018-10-01.

## Resources

| Resource |
| --- |
| יועץ עסקי |
| עמיתים |
| עורך דין |
| רשות ממשלתית |
| מנהל |
| בעלים |
| רואה חשבון |
| בנקאי |
| שירותי מידע |

## Schedule

| ID | WBS | Task | Type | Duration | Start | Finish | Predecessors | Total slack | Free slack | Resources | Work |
| --- | --- | --- | --- | --- | --- | --- | --- | --- | --- | --- | --- |
| 1 | 1 | **שלב 1 - תוכנית אסטרטגית** |  | 23d | 2018-05-21 | 2018-06-20 |  | 0d |  |  | 240h |
| 2 | 1.1 | **הערכה עצמית** |  | 3d | 2018-05-21 | 2018-05-23 |  | 0d |  |  | 32h |
| 3 | 1.1.1 | הגדרת החזון העסקי |  | 1d | 2018-05-21 | 2018-05-21 |  | 0d |  | מנהל | 8h |
| 4 | 1.1.2 | זיהוי כישורים זמינים, מידע ותמיכה |  | 1d | 2018-05-22 | 2018-05-22 | 3 | 0d |  | יועץ עסקי; מנהל | 16h |
| 5 | 1.1.3 | קבלת החלטה אם להמשיך |  | 1d | 2018-05-23 | 2018-05-23 | 4 | 0d |  | מנהל | 8h |
| 6 | 1.2 | **הגדרת ההזדמנות** |  | 10d | 2018-05-24 | 2018-06-06 |  | 0d |  |  | 96h |
| 7 | 1.2.1 | חקירת השוק והגורמים המתחרים |  | 1d | 2018-05-24 | 2018-05-24 | 5 | 0d |  | יועץ עסקי | 8h |
| 8 | 1.2.2 | עריכת ראיונות לבעלי עסקים דומים |  | 5d | 2018-05-27 | 2018-05-31 | 7 | 0d |  | בעלים | 40h |
| 9 | 1.2.3 | זיהוי משאבים דרושים |  | 2d | 2018-06-03 | 2018-06-04 | 8 | 0d |  | יועץ עסקי; עמיתים | 32h |
| 10 | 1.2.4 | זיהוי גורמים של עלות ההפעלה |  | 2d | 2018-06-05 | 2018-06-06 | 9 | 0d |  | רואה חשבון | 16h |
| 11 | 1.3 | **הערכת הגישה העסקית** |  | 4d | 2018-06-07 | 2018-06-12 |  | 0d |  |  | 32h |
| 12 | 1.3.1 | הגדרת דרישות הקשורות ליישות החדשה |  | 1d | 2018-06-07 | 2018-06-07 | 10 | 0d |  | מנהל | 8h |
| 13 | 1.3.2 | זיהוי הזדמנויות קיימות לרכישה עסקית |  | 1d | 2018-06-10 | 2018-06-10 | 12 | 0d |  | מנהל | 8h |
| 14 | 1.3.3 | חקירת אפשרויות זיכיון |  | 1d | 2018-06-11 | 2018-06-11 | 13 | 0d |  | מנהל | 8h |
| 15 | 1.3.4 | סיכום הגישה העסקית |  | 1d | 2018-06-12 | 2018-06-12 | 14 | 0d |  | מנהל | 8h |
| 16 | 1.4 | **הערכת סיכונים וגמולים פוטנציאליים** |  | 7d | 2018-06-10 | 2018-06-18 |  | 3d |  |  | 80h |
| 17 | 1.4.1 | הערכת גודל השוק ויציבותו |  | 2d | 2018-06-10 | 2018-06-11 | 12 | 104d | 0d | יועץ עסקי | 16h |
| 18 | 1.4.2 | הערכת המתחרים |  | 1d | 2018-06-12 | 2018-06-12 | 17 | 104d | 0d | יועץ עסקי | 8h |
| 19 | 1.4.3 | הערכת הזמינות של משאבים נחוצים |  | 2d | 2018-06-13 | 2018-06-14 | 18 | 104d | 0d | יועץ עסקי | 16h |
| 20 | 1.4.4 | הערכת פלח שוק התחלתי ריאלי |  | 1d | 2018-06-17 | 2018-06-17 | 19 | 104d |  | יועץ עסקי | 8h |
| 21 | 1.4.5 | קביעת הדרישות הכספיות |  | 2d | 2018-06-13 | 2018-06-14 | 15 | 0d |  | יועץ עסקי | 16h |
| 22 | 1.4.6 | סקירת התאמה אישית |  | 1d | 2018-06-17 | 2018-06-17 | 21 | 0d |  | מנהל | 8h |
| 23 | 1.4.7 | הערכת רווחיות התחלתית |  | 1d | 2018-06-18 | 2018-06-18 | 22 | 0d |  | מנהל | 8h |
| 24 | 1.5 | סקירה ושינוי של התוכנית האסטרטגית |  | 2d | 2018-06-19 | 2018-06-20 | 23 | 0d |  |  |  |
| 25 | 1.6 | אישור ההחלטה להמשיך | milestone | 0d | 2018-06-20 | 2018-06-20 | 24 | 0d |  |  |  |

| ID | WBS | Task | Type | Duration | Start | Finish | Predecessors | Total slack | Resources | Work |
| --- | --- | --- | --- | --- | --- | --- | --- | --- | --- | --- |
| 26 | 2 | **שלב 2 - הגדרת ההזדמנות העסקית** |  | 27d | 2018-06-21 | 2018-07-29 |  | 0d |  | 208h |
| 27 | 2.1 | **הגדרת השוק** |  | 13d | 2018-06-21 | 2018-07-09 |  | 0d |  | 104h |
| 28 | 2.1.1 | גישה למידע זמין |  | 1d | 2018-06-21 | 2018-06-21 | 25 | 0d | יועץ עסקי | 8h |
| 29 | 2.1.2 | יצירת תוכנית ניתוח שוק |  | 2d | 2018-06-24 | 2018-06-25 | 28 | 0d | יועץ עסקי | 16h |
| 30 | 2.1.3 | יישום תוכנית ניתוח שוק |  | 5d | 2018-06-26 | 2018-07-02 | 29 | 0d | יועץ עסקי | 40h |
| 31 | 2.1.4 | זיהוי המתחרים |  | 2d | 2018-07-03 | 2018-07-04 | 30 | 0d | יועץ עסקי | 16h |
| 32 | 2.1.5 | סיכום השוק |  | 2d | 2018-07-05 | 2018-07-08 | 31 | 0d | יועץ עסקי | 16h |
| 33 | 2.1.6 | זיהוי הנישה של שוק היעד |  | 1d | 2018-07-09 | 2018-07-09 | 32 | 0d | יועץ עסקי | 8h |
| 34 | 2.2 | **זיהוי האספקה והחומרים הדרושים** |  | 7d | 2018-07-10 | 2018-07-18 |  | 0d |  | 56h |
| 35 | 2.2.1 | בחירת גישה עסקית (מתוך "הערכת הגישה העסקית" לעיל) |  | 2d | 2018-07-10 | 2018-07-11 | 28SS, 33 | 0d | מנהל | 16h |
| 36 | 2.2.2 | זיהוי משאבי צוות ניהול |  | 1d | 2018-07-12 | 2018-07-12 | 35 | 0d | מנהל | 8h |
| 37 | 2.2.3 | זיהוי דרישות גיוס צוותים |  | 1d | 2018-07-15 | 2018-07-15 | 36 | 0d | מנהל | 8h |
| 38 | 2.2.4 | זיהוי חומרי גלם דרושים |  | 1d | 2018-07-16 | 2018-07-16 | 37 | 0d | מנהל | 8h |
| 39 | 2.2.5 | זיהוי שירותים דרושים |  | 1d | 2018-07-17 | 2018-07-17 | 38 | 0d | מנהל | 8h |
| 40 | 2.2.6 | סיכום הוצאות הפעלה והשלכות כספיות |  | 1d | 2018-07-18 | 2018-07-18 | 39 | 0d | מנהל | 8h |
| 41 | 2.3 | **הערכת סיכונים וגמולים פוטנציאליים** |  | 6d | 2018-07-19 | 2018-07-26 |  | 0d |  | 48h |
| 42 | 2.3.1 | הערכת גודל השוק ויציבותו |  | 2d | 2018-07-19 | 2018-07-22 | 40 | 0d | מנהל | 16h |
| 43 | 2.3.2 | הערכת הזמינות של משאבים דרושים |  | 2d | 2018-07-23 | 2018-07-24 | 42 | 0d | מנהל | 16h |
| 44 | 2.3.3 | חיזוי תשואות פיננסיות |  | 2d | 2018-07-25 | 2018-07-26 | 43 | 0d | רואה חשבון | 16h |
| 45 | 2.4 | סקירה ושינוי של ההזדמנות העסקית |  | 1d | 2018-07-29 | 2018-07-29 | 44 | 0d |  |  |
| 46 | 2.5 | אישור ההחלטה להמשיך | milestone | 0d | 2018-07-29 | 2018-07-29 | 45 | 0d | יועץ עסקי; עמיתים; עורך דין; רואה חשבון |  |
| 47 | 3 | **שלב 3 - תכנון הפעילות** |  | 21d | 2018-07-30 | 2018-08-27 |  | 0d |  | 184h |
| 48 | 3.1 | **פיתוח תוכנית חומש עסקית מפורטת** |  | 21d | 2018-07-30 | 2018-08-27 |  | 0d |  | 184h |
| 49 | 3.1.1 | תיאור החזון וההזדמנות |  | 1d | 2018-07-30 | 2018-07-30 | 46 | 0d | יועץ עסקי | 8h |
| 50 | 3.1.2 | פירוט הנחות העבודה |  | 1d | 2018-07-31 | 2018-07-31 | 49 | 0d | יועץ עסקי | 8h |
| 51 | 3.1.3 | תיאור השוק |  | 1d | 2018-08-01 | 2018-08-01 | 50 | 0d | יועץ עסקי | 8h |
| 52 | 3.1.4 | תיאור העסק החדש |  | 1d | 2018-08-02 | 2018-08-02 | 51 | 0d | יועץ עסקי | 8h |
| 53 | 3.1.5 | תיאור נקודות החוזק, נקודות התורפה, הנכסים והסכנות |  | 1d | 2018-08-05 | 2018-08-05 | 52 | 0d | יועץ עסקי | 8h |
| 54 | 3.1.6 | הערכת נפח המכירות במהלך התקופה ההתחלתית |  | 1d | 2018-08-06 | 2018-08-06 | 53 | 0d | יועץ עסקי; רואה חשבון | 16h |
| 55 | 3.1.7 | חיזוי עלויות הפעלה |  | 1d | 2018-08-07 | 2018-08-07 | 54 | 0d | יועץ עסקי; רואה חשבון | 16h |
| 56 | 3.1.8 | ביסוס אסטרטגיית תמחור |  | 1d | 2018-08-08 | 2018-08-08 | 55 | 0d | יועץ עסקי | 8h |
| 57 | 3.1.9 | חיזוי ההכנסות |  | 1d | 2018-08-09 | 2018-08-09 | 56 | 0d | יועץ עסקי | 8h |
| 58 | 3.1.10 | סיכום ההצהרה הפיננסית למען הסדר הטוב |  | 2d | 2018-08-12 | 2018-08-13 | 57 | 0d | יועץ עסקי | 16h |
| 59 | 3.1.11 | פיתוח תוכנית סיום ללא הפסדים |  | 1d | 2018-08-14 | 2018-08-14 | 58 | 0d | יועץ עסקי | 8h |
| 60 | 3.1.12 | פיתוח השלכת תזרים מזומנים |  | 1d | 2018-08-15 | 2018-08-15 | 59 | 0d | יועץ עסקי | 8h |
| 61 | 3.1.13 | זיהוי דרישות רישוי והיתרים |  | 1d | 2018-08-16 | 2018-08-16 | 60 | 0d | יועץ עסקי | 8h |
| 62 | 3.1.14 | פיתוח תוכנית הזנקה |  | 2d | 2018-08-19 | 2018-08-20 | 61 | 0d | יועץ עסקי | 16h |
| 63 | 3.1.15 | פיתוח אסטרטגיית מכירות ושיווק |  | 1d | 2018-08-21 | 2018-08-21 | 62 | 0d | יועץ עסקי | 8h |
| 64 | 3.1.16 | פיתוח מבנה הפצה |  | 1d | 2018-08-22 | 2018-08-22 | 63 | 0d | יועץ עסקי | 8h |
| 65 | 3.1.17 | תיאור סכנות והזדמנויות |  | 2d | 2018-08-23 | 2018-08-26 | 64 | 0d | יועץ עסקי | 16h |
| 66 | 3.1.18 | פרסום התוכנית העסקית |  | 1d | 2018-08-27 | 2018-08-27 | 65 | 0d | יועץ עסקי | 8h |
| 67 | 3.1.19 | אישור ההחלטה להמשיך | milestone | 0d | 2018-08-27 | 2018-08-27 | 66 | 0d | יועץ עסקי |  |

| ID | WBS | Task | Type | Duration | Start | Finish | Predecessors | Total slack | Free slack | Resources | Work |
| --- | --- | --- | --- | --- | --- | --- | --- | --- | --- | --- | --- |
| 68 | 4 | **שלב 4 - המשך תוכנית ההזנקה** |  | 53d | 2018-08-28 | 2018-11-21 |  | 0d |  |  | 736h |
| 69 | 4.1 | בחירת מיקום |  | 1d | 2018-08-28 | 2018-08-28 | 67 | 0d |  |  |  |
| 70 | 4.2 | **ביסוס מבנה עסקי** |  | 24d | 2018-08-29 | 2018-10-14 |  | 0d |  |  | 296h |
| 71 | 4.2.1 | **בחירת שם** |  | 2d | 2018-08-29 | 2018-08-30 |  | 0d |  |  | 16h |
| 72 | 4.2.1.1 | זיהוי ההשלכות |  | 1d | 2018-08-29 | 2018-08-29 | 69 | 0d |  | עורך דין | 8h |
| 73 | 4.2.1.2 | חקירת זמינות השם |  | 1d | 2018-08-30 | 2018-08-30 | 72 | 0d |  | עורך דין | 8h |
| 74 | 4.2.2 | **בחירת בנק** |  | 5d | 2018-09-02 | 2018-09-06 |  | 0d |  |  | 40h |
| 75 | 4.2.2.1 | פתיחת חשבונות |  | 4d | 2018-09-02 | 2018-09-05 | 73 | 0d |  | בנקאי | 32h |
| 76 | 4.2.2.2 | ביסוס מסלול אשראי |  | 1d | 2018-09-06 | 2018-09-06 | 75 | 0d |  | בנקאי | 8h |
| 77 | 4.2.3 | בחירת ייצוג משפטי |  | 1d | 2018-09-12 | 2018-09-12 | 75SS, 76 | 0d |  | עורך דין | 8h |
| 78 | 4.2.4 | בחירת קטגוריית בסיס מס עסקי |  | 2d | 2018-09-13 | 2018-09-16 | 77 | 0d |  | עורך דין; רואה חשבון | 32h |
| 79 | 4.2.5 | בחירת מקור מימון ראשי |  | 2d | 2018-09-17 | 2018-09-20 | 78 | 0d |  | מנהל | 16h |
| 80 | 4.2.6 | מסירת מימון הון | milestone | 0d | 2018-09-20 | 2018-09-20 | 79 | 13d | 0d | מנהל |  |
| 81 | 4.2.7 | **ייסוד בסיס בקרת ההפעלה** |  | 12d | 2018-09-25 | 2018-10-14 |  | 13d |  |  | 144h |
| 82 | 4.2.7.1 | בחירה והקמה של מערכת הנהלת חשבונות |  | 2d | 2018-09-25 | 2018-09-26 | 79, 80 | 13d | 0d | רואה חשבון | 16h |
| 83 | 4.2.7.2 | השגת הרשיונות וההיתרים הדרושים |  | 4d | 2018-09-27 | 2018-10-04 | 82 | 13d | 0d | עורך דין; רשות ממשלתית | 64h |
| 84 | 4.2.7.3 | השגת הביטוח הנדרש |  | 4d | 2018-10-07 | 2018-10-10 | 83 | 13d | 0d | רואה חשבון | 32h |
| 85 | 4.2.7.4 | ביסוס תוכנית אבטחה |  | 2d | 2018-10-11 | 2018-10-14 | 84 | 13d | 0d | יועץ עסקי; עורך דין | 32h |
| 86 | 4.2.8 | **פיתוח תוכנית שיווק** |  | 4d | 2018-08-30 | 2018-09-04 |  | 32d |  |  | 40h |
| 87 | 4.2.8.1 | ביסוס תוכנית פרסום |  | 2d | 2018-08-30 | 2018-09-02 | 73SS | 32d | 0d | יועץ עסקי | 16h |
| 88 | 4.2.8.2 | פיתוח לוגו |  | 1d | 2018-09-03 | 2018-09-03 | 87 | 32d | 0d | יועץ עסקי; עורך דין | 16h |
| 89 | 4.2.8.3 | הזמנת חומרי קידום מכירות |  | 1d | 2018-09-04 | 2018-09-04 | 88 | 32d | 19d | יועץ עסקי | 8h |
| 90 | 4.3 | **אספקת המתקנים הפיזיים** |  | 15d | 2018-10-15 | 2018-11-04 |  | 13d |  |  | 120h |
| 91 | 4.3.1 | השגת מרחב פעולה |  | 5d | 2018-10-15 | 2018-10-21 | 85, 89 | 13d | 0d | עורך דין | 40h |
| 92 | 4.3.2 | בחירת חומרת רשת מחשבים |  | 1d | 2018-10-22 | 2018-10-22 | 91 | 13d | 0d | שירותי מידע | 8h |
| 93 | 4.3.3 | בחירת תוכנת מחשבים |  | 1d | 2018-10-23 | 2018-10-23 | 92 | 13d | 0d | שירותי מידע | 8h |
| 94 | 4.3.4 | ביסוס שירותים |  | 3d | 2018-10-24 | 2018-10-28 | 93 | 13d | 0d | מנהל | 24h |
| 95 | 4.3.5 | אספקת ריהוט וציוד |  | 4d | 2018-10-29 | 2018-11-01 | 94 | 13d | 0d | מנהל | 32h |
| 96 | 4.3.6 | מעבר למקום החדש |  | 1d | 2018-11-04 | 2018-11-04 | 95 | 13d |  | מנהל | 8h |

| ID | WBS | Task | Type | Duration | Start | Finish | Predecessors | Total slack | Resources | Work |
| --- | --- | --- | --- | --- | --- | --- | --- | --- | --- | --- |
| 97 | 4.4 | **אספקת צוותים** |  | 40d | 2018-09-25 | 2018-11-21 |  | 0d |  | 320h |
| 98 | 4.4.1 | עריכת ראיונות ובחינת מועמדים |  | 14d | 2018-09-25 | 2018-10-16 | 79 | 0d | מנהל | 112h |
| 99 | 4.4.2 | שכירת צוות |  | 10d | 2018-10-17 | 2018-10-30 | 98 | 0d | מנהל | 80h |
| 100 | 4.4.3 | הכשרת הצוות |  | 16d | 2018-10-31 | 2018-11-21 | 99 | 0d | מנהל | 128h |
| 101 | 4.5 | הפעלת העסק | milestone | 0d | 2018-11-21 | 2018-11-21 | 96, 100 | 0d | מנהל |  |
